# elijahs project

Schedule from MS Project, 2009-05-06 to 2009-06-30, costs in $.
uncw

## Calendars

- Standard: Mon-Fri 08:00-12:00, 13:00-17:00; Sat-Sun off.

## Resources

| Resource | Rate | Notes |
| --- | --- | --- |
| Project Manager | 37.5 |  |
| Graphics designer | 19.71 |  |
| Instructional Designer | 26.44 |  |
| SME |  | There is no cost for the SME |
| Printer | 300 |  |
| Presentation Equipment |  |  |
| Writer/Editor | 25.96 |  |
| Test developer | 25.96 |  |

## Schedule

| ID | WBS | Task | Type | Duration | Start | Finish | Predecessors | Baseline start | Baseline finish | Baseline duration | Total slack | Free slack | Constraint | Resources | Work | Cost |
| --- | --- | --- | --- | --- | --- | --- | --- | --- | --- | --- | --- | --- | --- | --- | --- | --- |
| 1 | 1 | Start Project | milestone | 0d | 2009-05-06 08:00 | 2009-05-06 08:00 |  | 2009-05-25 08:00 | 2009-05-25 10:00 | 0.25d | 0.75d | 0d | start no earlier than 2009-05-06 08:00 | Instructional Designer; Project Manager; Writer/Editor; SME |  |  |
| 2 | 2 | **Phase One: Project Planning** |  | 6.12d | 2009-05-06 08:00 | 2009-05-14 09:00 | 1 | 2009-05-25 10:00 | 2009-05-26 10:00 | 1d | 0d |  |  | Instructional Designer; Project Manager; Writer/Editor; Test developer; SME; Graphics designer [50%] | 500.5h | 11,302.64 |
| 3 | 2.1 | Develop project plan |  | 5d | 2009-05-06 08:00 | 2009-05-12 17:00 | 1 |  |  |  | 0d |  |  | Graphics designer [50%]; Instructional Designer; Project Manager; SME; Test developer [50%]; Writer/Editor | 200h | 4,509.62 |
| 4 | 2.2 | Delegate project tasks |  | 1h | 2009-05-13 08:00 | 2009-05-13 09:00 | 3 |  |  |  | 0d |  |  | Project Manager | 1h | 37.5 |
| 5 | 2.3 | Distribute project plan |  | 2h | 2009-05-13 09:00 | 2009-05-13 11:00 | 4 |  |  |  | 0d |  |  | Instructional Designer | 2h | 52.88 |
| 6 | 2.4 | **Select training location** |  | 0.75d | 2009-05-13 11:00 | 2009-05-14 09:00 | 5 | 2009-05-26 10:00 | 2009-05-28 10:00 | 2d? | 0d |  |  | Instructional Designer; Project Manager; SME | 28h | 542.31 |
| 7 | 2.4.1 | Arrange training space |  | 2h | 2009-05-13 11:00 | 2009-05-13 14:00 | 5 | 2009-05-26 10:00 | 2009-05-27 10:00 | 1d? | 0d |  |  | Instructional Designer; SME | 4h | 52.88 |
| 8 | 2.4.2 | Arrange presentation equipment |  | 2h | 2009-05-13 14:00 | 2009-05-13 16:00 | 7 | 2009-05-27 10:00 | 2009-05-28 10:00 | 1d? | 0d |  |  | Instructional Designer | 2h | 52.88 |
| 9 | 2.4.3 | Set date and time for training |  | 2h | 2009-05-13 16:00 | 2009-05-14 09:00 | 8 |  |  |  | 0d |  |  | Instructional Designer; SME | 4h | 52.88 |
| 10 | 3 | Phase One Project Planning Complete | milestone | 0d | 2009-05-14 09:00 | 2009-05-14 09:00 | 9 |  |  |  | 0d |  | finish no earlier than 2009-05-07 17:00 |  |  |  |
| 11 | 4 | **PhaseTwo: Plan Content** |  | 24.88d | 2009-05-14 09:00 | 2009-06-17 17:00 | 10 | 2009-05-26 10:00 | 2009-06-02 15:00 | 5.5d? | 0d |  |  | Instructional Designer; Project Manager; Test developer; SME; Writer/Editor; Graphics designer | 2098.1h | 50,234.09 |
| 12 | 4.1 | **Part One** |  | 0.62d | 2009-05-14 09:00 | 2009-05-14 15:00 | 10 |  |  |  | 0d |  |  | Instructional Designer; Project Manager; SME | 30h | 639.42 |
| 13 | 4.1.1 | decide on content - topics, procedure |  | 5h | 2009-05-14 09:00 | 2009-05-14 15:00 | 5 |  |  |  | 0d |  |  | Instructional Designer; Project Manager; SME | 15h | 319.71 |
| 14 | 4.2 | **Part Two - design instructional strategies** |  | 5.25d | 2009-05-14 15:00 | 2009-05-21 17:00 | 13 |  |  |  | 0d |  |  | Graphics designer [50%]; Instructional Designer; Writer/Editor; Test developer [50%] | 160h | 3,968.75 |
| 15 | 4.2.1 | prepare objectives |  | 2h | 2009-05-14 15:00 | 2009-05-14 17:00 | 13 | 2009-05-26 10:00 | 2009-05-26 13:40 | 0.33d? | 0d |  |  | Instructional Designer; Project Manager; SME | 6h | 127.88 |
| 16 | 4.2.2 | design graphics/images |  | 2d | 2009-05-15 08:00 | 2009-05-18 17:00 | 15 |  |  |  | 0d |  |  | Graphics designer [50%] | 8h | 157.69 |
| 17 | 4.2.3 | design formative evaluation |  | 1d | 2009-05-19 08:00 | 2009-05-19 17:00 | 16 |  |  |  | 0d |  |  | Test developer [50%]; Instructional Designer | 12h | 315.38 |
| 18 | 4.2.4 | design test items |  | 2d | 2009-05-20 08:00 | 2009-05-21 17:00 | 17 |  |  |  | 0d |  |  | Test developer [50%] | 8h | 207.69 |
| 19 | 4.3 | **Part Three - develop materials** |  | 5d | 2009-05-22 08:00 | 2009-05-28 17:00 | 18 |  |  |  | 0d |  |  | Test developer [50%]; Graphics designer [50%]; Instructional Designer; Writer/Editor | 188h | 4,736.54 |
| 20 | 4.3.1 | develop test items |  | 1d | 2009-05-22 08:00 | 2009-05-22 17:00 | 18 | 2009-05-26 13:40 | 2009-05-27 13:40 | 1d? | 0d |  |  | Test developer | 8h | 207.69 |
| 21 | 4.3.2 | develop graphics |  | 1d | 2009-05-25 08:00 | 2009-05-25 17:00 | 20 | 2009-05-27 13:40 | 2009-05-28 13:40 | 1d? | 0d |  |  | Graphics designer | 8h | 157.69 |
| 22 | 4.3.3 | develop job aids |  | 1d | 2009-05-26 08:00 | 2009-05-26 17:00 | 21 | 2009-05-28 13:40 | 2009-05-29 08:40 | 0.5d? | 0d |  |  | Writer/Editor; Instructional Designer | 16h | 419.23 |
| 23 | 4.3.4 | develop managerial checklist |  | 1d | 2009-05-27 08:00 | 2009-05-27 17:00 | 22 | 2009-05-29 08:40 | 2009-05-29 11:20 | 0.33d? | 0d |  |  | Instructional Designer; Writer/Editor | 16h | 419.23 |
| 24 | 4.3.5 | develop formative evaluation |  | 1d | 2009-05-28 08:00 | 2009-05-28 17:00 | 23 |  |  |  | 0d |  |  | Test developer [50%]; Writer/Editor; Instructional Designer | 20h | 523.08 |

Notes:
- 6: Location for training the trainers

| ID | WBS | Task | Type | Duration | Start | Finish | Predecessors | Baseline start | Baseline finish | Baseline duration | Total slack | Constraint | Resources | Work | Cost |
| --- | --- | --- | --- | --- | --- | --- | --- | --- | --- | --- | --- | --- | --- | --- | --- |
| 25 | 4.4 | **Part Four - prepare training materials** |  | 6d | 2009-05-29 08:00 | 2009-06-05 17:00 | 24 | 2009-05-29 11:20 | 2009-05-29 16:20 | 0.5d? | 0d |  | Instructional Designer; Writer/Editor | 272h | 6,857.69 |
| 26 | 4.4.1 | Design Student Manual |  | 0.5d | 2009-05-29 08:00 | 2009-05-29 12:00 | 24 |  |  |  | 0d |  | Writer/Editor; Instructional Designer | 8h | 209.62 |
| 27 | 4.4.2 | Design Instructor Manual |  | 0.5d | 2009-05-29 13:00 | 2009-05-29 17:00 | 26 |  |  |  | 0d |  | Writer/Editor; Instructional Designer | 8h | 209.62 |
| 28 | 4.4.3 | develop 1st draft products - beta |  | 5d | 2009-06-01 08:00 | 2009-06-05 17:00 | 27 | 2009-06-02 10:00 | 2009-06-02 12:00 | 0.25d? | 0d |  | Instructional Designer; Graphics designer; Test developer; Writer/Editor | 160h | 3,923.08 |
| 29 | 4.5 | **Part Five - Evaluation of Products and Revision** |  | 1.38d | 2009-06-08 08:00 | 2009-06-09 11:00 | 28 |  |  |  | 0d |  | Project Manager; Instructional Designer; SME | 58h | 1,314.42 |
| 30 | 4.5.1 | Expert review 1st draft products |  | 3h | 2009-06-08 08:00 | 2009-06-08 11:00 | 28 |  |  |  | 0d |  | SME; Instructional Designer; Project Manager | 9h | 191.83 |
| 31 | 4.5.2 | revise products |  | 1d | 2009-06-08 11:00 | 2009-06-09 11:00 | 30 |  |  |  | 0d |  | Instructional Designer; Writer/Editor | 16h | 419.23 |
| 32 | 4.6 | **Part Six - Prepare awareness activities** |  | 1d | 2009-06-09 11:00 | 2009-06-10 11:00 | 31 |  |  |  | 0d |  | Writer/Editor [60%]; Instructional Designer | 25.6h | 672.31 |
| 33 | 4.6.1 | design presentation and activities |  | 0.5d | 2009-06-09 11:00 | 2009-06-09 16:00 | 31 |  |  |  | 0d |  | Writer/Editor [60%]; Instructional Designer | 6.4h | 168.08 |
| 34 | 4.6.2 | develop presentation and activities |  | 0.5d | 2009-06-09 16:00 | 2009-06-10 11:00 | 33 |  |  |  | 0d |  | Writer/Editor [60%]; Instructional Designer | 6.4h | 168.08 |
| 35 | 4.7 | **Part Seven - conduct formative evaluation-materials** |  | 3.62d | 2009-06-10 11:00 | 2009-06-15 17:00 | 34 | 2009-06-02 15:00 | 2009-06-04 10:00 | 1.5d? | 0d |  | Test developer; Instructional Designer; SME | 138.5h | 4,218.99 |
| 36 | 4.7.1 | one on one evaluation |  | 1d | 2009-06-10 11:00 | 2009-06-11 11:00 | 34 |  |  |  | 0d |  | Test developer [50%]; Instructional Designer | 12h | 315.38 |
| 37 | 4.7.2 | small group evaluation of materials |  | 1d | 2009-06-11 11:00 | 2009-06-12 11:00 | 36 | 2009-06-02 15:00 | 2009-06-03 10:00 | 0.5d? | 0d |  | Test developer; Instructional Designer | 16h | 419.23 |
| 38 | 4.7.3 | revise materials |  | 1d | 2009-06-12 11:00 | 2009-06-15 11:00 | 37 | 2009-06-03 10:00 | 2009-06-04 10:00 | 1d? | 0d |  | Test developer; Writer/Editor | 16h | 415.38 |
| 39 | 4.7.4 | print materials |  | 5h | 2009-06-15 11:00 | 2009-06-15 17:00 | 38 |  |  |  | 0d |  | Graphics designer [50%]; Printer | 7.5h | 1,549.28 |
| 40 | 4.8 | **Part Eight - Packaging and Distribution** |  | 2d | 2009-06-16 08:00 | 2009-06-17 17:00 | 39 |  |  |  | 0d |  | Instructional Designer | 32h | 846.15 |
| 41 | 4.8.1 | Package products |  | 1d | 2009-06-16 08:00 | 2009-06-16 17:00 | 39 |  |  |  | 0d |  | Instructional Designer | 8h | 211.54 |
| 42 | 4.8.2 | distribute products |  | 1d | 2009-06-17 08:00 | 2009-06-17 17:00 | 41 |  |  |  | 0d |  | Instructional Designer | 8h | 211.54 |
| 43 | 5 | Phase Two Plan Content Complete | milestone | 0d | 2009-06-17 17:00 | 2009-06-17 17:00 | 42 |  |  |  | 0d | finish no earlier than 2009-06-11 17:00 |  |  |  |
| 44 | 6 | **Phase Three - train instructors** |  | 1.38d | 2009-06-18 08:00 | 2009-06-19 11:00 | 43 | 2009-06-04 10:00 | 2009-06-04 15:00 | 0.5d | 0d |  | Instructional Designer | 22h | 581.73 |
| 45 | 6.1 | Conduct training |  | 1d | 2009-06-18 08:00 | 2009-06-18 17:00 | 43 |  |  |  | 0d |  | Instructional Designer | 8h | 211.54 |
| 46 | 6.2 | Complete training |  | 3h | 2009-06-19 08:00 | 2009-06-19 11:00 | 45 |  |  |  | 0d |  | Instructional Designer | 3h | 79.33 |
| 47 | 7 | Phase Three Train Instructors Complete | milestone | 0d | 2009-06-19 11:00 | 2009-06-19 11:00 | 46 |  |  |  | 0d |  |  |  |  |
| 48 | 8 | **Phase Four - evaluate training** |  | 0.5d | 2009-06-19 11:00 | 2009-06-19 16:00 | 47 | 2009-05-25 08:00 | 2009-05-27 17:00 | 3d? | 0d |  | Test developer; Instructional Designer; SME | 18h | 365.38 |
| 49 | 8.1 | Prepare Evaluation materials |  | 4h | 2009-06-19 11:00 | 2009-06-19 16:00 | 47 |  |  |  | 0d |  | Test developer [50%]; Writer/Editor | 6h | 155.77 |
| 50 | 9 | Phase Four Evaluate Training Complete | milestone | 0d | 2009-06-19 16:00 | 2009-06-19 16:00 | 49 |  |  |  | 0d |  |  |  |  |

| ID | WBS | Task | Type | Duration | Start | Finish | Predecessors | Baseline start | Baseline finish | Baseline duration | Total slack | Constraint | Resources | Work | Cost |
| --- | --- | --- | --- | --- | --- | --- | --- | --- | --- | --- | --- | --- | --- | --- | --- |
| 51 | 10 | **Phase Five - conduct summative evaluation** |  | 7d | 2009-06-19 16:00 | 2009-06-30 16:00 | 50 | 2009-05-27 08:00 | 2009-05-27 17:00 | 1d? | 0d |  | Instructional Designer; Project Manager; SME; Test developer [50%] | 260h | 5,992.31 |
| 52 | 10.1 | evaluate transfer of skills and knowledge |  | 2d | 2009-06-19 16:00 | 2009-06-23 16:00 | 50 | 2009-05-25 08:00 | 2009-05-25 12:00 | 0.5d | 0d | finish no later than 2009-06-24 17:00 | Instructional Designer | 16h | 423.08 |
| 53 | 10.2 | evaluate impact on performance decrement |  | 2d | 2009-06-23 16:00 | 2009-06-25 16:00 | 52 | 2009-05-25 13:00 | 2009-05-25 17:00 | 0.5d? | 0d |  | Instructional Designer | 16h | 423.08 |
| 54 | 10.3 | write report |  | 2d | 2009-06-25 16:00 | 2009-06-29 16:00 | 53 | 2009-05-26 08:00 | 2009-05-26 17:00 | 1d? | 0d |  | Instructional Designer; Writer/Editor | 32h | 838.46 |
| 55 | 10.4 | Submit Completed Report to Owner and General Manager |  | 1d | 2009-06-29 16:00 | 2009-06-30 16:00 | 54 |  |  |  | 0d | start no earlier than 2009-06-24 08:00 |  |  |  |
| 56 | 10.5 | Elijah's Project Complete | milestone | 0d | 2009-06-30 16:00 | 2009-06-30 16:00 | 55 |  |  |  | 0d |  |  |  |  |
